Schedule from GanttProject, 2009-04-13 to 2010-02-04.

## Calendars

- Project calendar: Mon-Fri working; Sat-Sun off.

## Resources

| Resource |
| --- |
| BL - LAVENIER Benoit |
| HG - GILES Henri |
| SB - BOCANDE Stephane |
| VP - PRIGENT Valérie |
| Sodifrance |
| PL - LESPAGNOL Patrick |
| CM - MERRIEN Claude |

## Schedule

| ID | WBS | Task | Type | Duration | Start | Finish | Predecessors | Complete | Resources |
| --- | --- | --- | --- | --- | --- | --- | --- | --- | --- |
| 1 | 1 | **Contenu et conceptualisation des référentiels** |  | 13d | 2009-04-16 | 2009-05-04 |  |  |  |
| 2 | 1.1 | Engins |  | 12d | 2009-04-16 | 2009-05-01 |  |  |  |
| 3 | 1.2 | **Espèces** |  | 2d | 2009-04-16 | 2009-04-17 |  |  |  |
| 4 | 1.2.1 | E. Scientifique |  | 1d | 2009-04-16 | 2009-04-16 |  |  |  |
| 5 | 1.2.2 | E. Commerciale |  | 2d | 2009-04-16 | 2009-04-17 |  |  |  |
| 6 | 1.3 | **Métiers** |  | 11d | 2009-04-20 | 2009-05-04 |  |  |  |
| 7 | 1.3.1 | Engin |  | 1d | 2009-05-04 | 2009-05-04 | 2 |  |  |
| 8 | 1.3.2 | Espèce(s) cible(s) |  | 1d | 2009-04-20 | 2009-04-20 | 5 |  |  |
| 9 | 1.4 | **PSFM** |  | 1d | 2009-04-16 | 2009-04-16 |  |  |  |
| 10 | 1.4.1 | Activité |  | 1d | 2009-04-16 | 2009-04-16 |  |  |  |
| 11 | 1.4.2 | ObsMer |  | 1d | 2009-04-16 | 2009-04-16 |  |  |  |
| 12 | 1.4.3 | SACAPT |  | 1d | 2009-04-16 | 2009-04-16 |  |  |  |
| 13 | 1.4.4 | Effort |  | 1d | 2009-04-16 | 2009-04-16 |  |  |  |
| 14 | 2 | **Allegro** |  | 214d | 2009-04-13 | 2010-02-04 |  | 9% |  |
| 15 | 2.1 | **v1.1 Enquete activité (Statpeche)** |  | 14d | 2009-04-16 | 2009-05-05 |  |  |  |
| 16 | 2.1.1 | Tests et corrections |  | 10d | 2009-04-16 | 2009-04-29 |  |  | HG - GILES Henri; VP - PRIGENT Valérie [80%] |
| 17 | 2.1.2 | Migration des données |  | 5d | 2009-04-21 | 2009-04-27 |  |  | BL - LAVENIER Benoit |
| 18 | 2.1.3 | Mise en exploitation | milestone | 0d | 2009-05-05 | 2009-05-05 | 6, 9, 17 |  |  |
| 19 | 2.2 | **v1.2 Marées observée en mer (ObsMer)** |  | 98d | 2009-04-16 | 2009-08-31 |  |  |  |
| 20 | 2.2.1 | Tests et corrections |  | 60d | 2009-04-16 | 2009-07-08 |  |  | HG - GILES Henri; SB - BOCANDE Stephane [25%]; VP - PRIGENT Valérie [80%] |
| 21 | 2.2.2 | Migration des données |  | 40d | 2009-07-06 | 2009-08-28 |  |  | BL - LAVENIER Benoit |
| 22 | 2.2.3 | Mise en exploitation | milestone | 0d | 2009-08-31 | 2009-08-31 | 6, 7, 9, 20, 21 |  |  |
| 23 | 2.3 | **v2.1 Engins physiques et effort (Statpeche)** |  | 127d | 2009-04-16 | 2009-10-09 |  |  |  |
| 24 | 2.3.1 | Développements |  | 64d | 2009-04-16 | 2009-07-14 |  |  | Sodifrance |
| 25 | 2.3.2 | Tests et corrections |  | 62d | 2009-07-15 | 2009-10-08 | 24 |  | HG - GILES Henri; VP - PRIGENT Valérie [80%] |
| 26 | 2.3.3 | Migration des données |  | 40d | 2009-07-06 | 2009-08-28 |  |  | BL - LAVENIER Benoit |
| 27 | 2.3.4 | Mise en exploitation | milestone | 0d | 2009-10-09 | 2009-10-09 | 13, 25, 26 |  |  |

| ID | WBS | Task | Type | Duration | Start | Finish | Predecessors | Complete | Resources |
| --- | --- | --- | --- | --- | --- | --- | --- | --- | --- |
| 28 | 2.4 | **v2.2 Fonctions d'adminitration des référentiels** |  | 31d | 2009-04-16 | 2009-05-28 |  | 8% |  |
| 29 | 2.4.1 | Spécifications |  | 5d | 2009-04-16 | 2009-04-22 |  | 50% | BL - LAVENIER Benoit; HG - GILES Henri |
| 30 | 2.4.2 | Développements |  | 15d | 2009-04-23 | 2009-05-13 | 29 |  | Sodifrance |
| 31 | 2.4.3 | Tests et corrections |  | 10d | 2009-05-14 | 2009-05-27 | 30 |  | HG - GILES Henri; VP - PRIGENT Valérie [80%] |
| 32 | 2.4.4 | Mise en exploitation | milestone | 0d | 2009-05-28 | 2009-05-28 | 31 |  |  |
| 33 | 2.5 | **v2.3 Marée observées au débarquement (ObsDeb)** |  | 203d | 2009-04-16 | 2010-01-25 |  | 26% |  |
| 34 | 2.5.1 | Spécifications |  | 15d | 2009-07-13 | 2009-07-31 |  |  |  |
| 35 | 2.5.2 | Développements |  | 95d | 2009-08-03 | 2009-12-11 | 34 |  |  |
| 36 | 2.5.3 | Tests et corrections |  | 30d | 2009-12-14 | 2010-01-22 | 35 |  |  |
| 37 | 2.5.4 | Migration des données |  | 50d | 2009-04-16 | 2009-06-24 |  | 50% |  |
| 38 | 2.5.5 | Mise en exploitation | milestone | 0d | 2010-01-25 | 2010-01-25 | 9, 36, 37 |  |  |
| 39 | 2.6 | **v2.4 Echantillonnage biologique (Arpège)** |  | 87d | 2009-05-15 | 2009-09-14 |  |  |  |
| 40 | 2.6.1 | Spécifications |  | 10d | 2009-05-15 | 2009-05-28 |  |  |  |
| 41 | 2.6.2 | Développements |  | 56d | 2009-05-29 | 2009-08-14 | 40 |  |  |
| 42 | 2.6.3 | Tests et corrections |  | 20d | 2009-08-17 | 2009-09-11 | 41 |  |  |
| 43 | 2.6.4 | Migration des données |  | 20d | 2009-05-29 | 2009-06-25 | 40 |  |  |
| 44 | 2.6.5 | Mise en exploitation | milestone | 0d | 2009-09-14 | 2009-09-14 | 3, 4, 5, 42, 43 |  |  |
| 45 | 2.7 | **v3.X Campagne à la mer** |  | 4d | 2010-01-26 | 2010-01-29 | 33, 39 |  |  |
| 46 | 2.7.1 | Spécifications |  | 1d | 2010-01-26 | 2010-01-26 |  |  |  |
| 47 | 2.7.2 | Développement |  | 1d | 2010-01-27 | 2010-01-27 | 46 |  |  |
| 48 | 2.7.3 | Tests et correction |  | 1d | 2010-01-28 | 2010-01-28 | 47 |  |  |
| 49 | 2.7.4 | Migration des données |  | 1d | 2010-01-27 | 2010-01-27 | 46 |  |  |
| 50 | 2.7.5 | Mise en exploitation | milestone | 0d | 2010-01-29 | 2010-01-29 | 48, 49 |  |  |
| 51 | 2.8 | **v3.X Enquetes economiques (Festif)** |  | 4d | 2010-02-01 | 2010-02-04 |  |  |  |
| 52 | 2.8.1 | Spécifications |  | 1d | 2010-02-01 | 2010-02-01 | 45 |  |  |
| 53 | 2.8.2 | Développements |  | 1d | 2010-02-02 | 2010-02-02 | 52 |  |  |
| 54 | 2.8.3 | Tests et corrections |  | 1d | 2010-02-03 | 2010-02-03 | 53 |  |  |
| 55 | 2.8.4 | Migration des données |  | 1d | 2010-02-02 | 2010-02-02 | 52 |  |  |
| 56 | 2.8.5 | Mise en exploitation | milestone | 0d | 2010-02-04 | 2010-02-04 | 54, 55 |  |  |
| 57 | 2.9 | Formation des utilisateurs |  | 1d | 2009-04-13 | 2009-04-13 |  |  |  |

| ID | WBS | Task | Type | Duration | Start | Finish | Predecessors |
| --- | --- | --- | --- | --- | --- | --- | --- |
| 58 | 3 | **V1.3 Allegro Mobile** |  | 102d | 2009-04-13 | 2009-09-01 |  |
| 59 | 3.1 | Développements |  | 1d | 2009-04-13 | 2009-04-13 |  |
| 60 | 3.2 | Tests et correction |  | 1d | 2009-04-13 | 2009-04-13 |  |
| 61 | 3.3 | Mise en exploitation | milestone | 0d | 2009-09-01 | 2009-09-01 | 19, 75 |
| 62 | 4 | **SIPA** |  | 14d | 2009-04-16 | 2009-05-05 |  |
| 63 | 4.1 | VMS |  | 1d | 2009-04-16 | 2009-04-16 |  |
| 64 | 4.2 | **RIC2** |  | 2d | 2009-04-16 | 2009-04-17 |  |
| 65 | 4.2.1 | Tests et corrections |  | 1d | 2009-04-16 | 2009-04-16 |  |
| 66 | 4.2.2 | Migration des données |  | 1d | 2009-04-16 | 2009-04-16 |  |
| 67 | 4.2.3 | Mise en exploitation | milestone | 0d | 2009-04-17 | 2009-04-17 | 65, 66 |
| 68 | 4.3 | **SACAPT** |  | 13d | 2009-04-16 | 2009-05-04 |  |
| 69 | 4.3.1 | Développements |  | 1d | 2009-04-16 | 2009-04-16 |  |
| 70 | 4.3.2 | Tests te corrections |  | 1d | 2009-04-17 | 2009-04-17 | 69 |
| 71 | 4.3.3 | Migration des données |  | 1d | 2009-04-16 | 2009-04-16 |  |
| 72 | 4.3.4 | Mise en exploitation | milestone | 0d | 2009-05-04 | 2009-05-04 | 2, 3, 70, 71 |
| 73 | 4.4 | **SACROIS** |  | 14d | 2009-04-16 | 2009-05-05 |  |
| 74 | 4.4.1 | Développements |  | 1d | 2009-04-16 | 2009-04-16 |  |
| 75 | 4.4.2 | Tests et corrections |  | 1d | 2009-04-17 | 2009-04-17 | 74 |
| 76 | 4.4.3 | Mise en exploitation | milestone | 0d | 2009-05-05 | 2009-05-05 | 64, 68, 75 |
